# RIVERBENDWTP

Schedule from Primavera P6, 2026-03-02 to 2027-02-22, data date 2026-08-28, A marks actual dates.

## Calendars

- Standard: Mon-Fri 08:00-12:00, 13:00-17:00; Sat-Sun off.

## Resources

| Resource | Group |
| --- | --- |
| Civil Crew A | labor |
| Project Controls | labor |
| Design Team | labor |
| Procurement | labor |
| Civil Crew B | labor |
| Mechanical Crew | labor |
| Electrical Crew | labor |
| Commissioning Team | labor |

## Schedule

| ID | WBS | Activity | Type | Duration | Start | Finish | Predecessors | Complete | Remaining | Planned start | Planned finish | Total float | Constraint | Resources |
| --- | --- | --- | --- | --- | --- | --- | --- | --- | --- | --- | --- | --- | --- | --- |
|  |  | **Riverbend WTP Upgrade - Update 06 (Sample Project)** |  |  | 2026-03-02 | 2027-02-22 |  |  |  |  |  |  |  |  |
|  | 1 | **1 PROJECT INITIATION** |  |  | 2026-03-02 | 2026-03-20 |  |  |  |  |  |  |  |  |
| A2 |  | Notice to proceed | milestone | 0d | 2026-03-02 A | 2026-03-02 A |  | 100% |  |  |  |  | mandatory start 2026-03-02 |  |
| A3 |  | Mobilise site facilities |  | 10d | 2026-03-02 A | 2026-03-13 A | A2 | 100% |  |  |  |  |  | Civil Crew A [80 h] |
| A4 |  | Baseline schedule approved |  | 8d | 2026-03-02 A | 2026-03-11 A | A2 | 100% |  |  |  |  |  | Project Controls [64 h] |
| A6 |  | Permits and consents confirmed |  | 15d | 2026-03-02 A | 2026-03-20 | A2 | 60% | 6d |  |  | 241d |  |  |
| A5 |  | Site survey and geotech verification |  | 12d | 2026-03-04 A | 2026-03-19 A | A3 SS+2d | 100% |  |  |  |  |  | Design Team [96 h] |
|  | 2 | **2 DETAILED DESIGN** |  |  | 2026-03-20 | 2026-06-04 |  |  |  |  |  |  |  |  |
| A8 |  | Process design report |  | 23d | 2026-03-20 A | 2026-04-21 A | A4, A5 | 100% |  | 2026-03-20 | 2026-04-16 |  |  | Design Team [184 h] |
| A9 |  | Civil and structural design |  | 29d | 2026-03-27 A | 2026-05-06 A | A8 SS+5d | 100% |  | 2026-03-27 | 2026-04-30 |  |  | Design Team [232 h] |
| A10 |  | Mechanical design |  | 22d | 2026-04-01 A | 2026-04-30 A | A8 SS+8d | 100% |  |  |  |  |  | Design Team [176 h] |
| A11 |  | Electrical and controls design |  | 24d | 2026-04-08 A | 2026-05-11 A | A10 SS+5d | 100% |  |  |  |  |  | Design Team [192 h] |
| A12 |  | HAZOP workshop and close-out |  | 8d | 2026-05-12 A | 2026-05-21 A | A9, A10, A11 | 100% |  |  |  |  |  | Design Team [64 h] |
| A14 |  | Design review milestone | milestone | 0d | 2026-05-21 A | 2026-05-21 A | A12 | 100% |  |  |  |  |  |  |
| A13 |  | Issued for construction drawings |  | 10d | 2026-05-22 A | 2026-06-04 A | A12 | 100% |  |  |  |  |  | Design Team [80 h] |
|  | 3 | **3 PROCUREMENT** |  |  | 2026-03-02 | 2026-08-31 |  |  |  |  |  |  |  |  |
| A21 |  | Spare parts and consumables order |  | 20d | 2026-03-02 A | 2026-03-27 |  | 60% | 8d |  |  | 236d |  | Procurement [160 h] |
| A16 |  | Membrane skid supply contract |  | 12d | 2026-04-22 A | 2026-05-07 A | A8 | 100% |  | 2026-04-17 | 2026-05-04 |  |  | Procurement [96 h] |
| A18 |  | Blowers and pumps procurement |  | 45d | 2026-05-01 A | 2026-07-02 A | A10 | 100% |  |  |  |  |  | Procurement [360 h] |
| A17 |  | Membrane skids fabrication and delivery |  | 82d | 2026-05-08 A | 2026-08-31 | A16 | 98% | 1.64d | 2026-05-05 | 2026-07-27 | 35d |  | Procurement [656 h] |
| A19 |  | Switchboard and VSD procurement |  | 58d | 2026-05-12 A | 2026-07-30 A | A11 | 100% |  | 2026-05-12 | 2026-07-20 |  |  | Procurement [464 h] |
| A20 |  | Instrumentation package |  | 35d | 2026-05-12 A | 2026-06-29 A | A11 | 100% |  |  |  |  |  | Procurement [280 h] |
|  | 4 | **4 CIVIL WORKS** |  |  | 2026-06-05 | 2026-10-19 |  |  |  |  |  |  |  |  |
| A23 |  | Bulk earthworks |  | 19d | 2026-06-05 A | 2026-07-01 A | A13 | 100% |  | 2026-06-05 | 2026-06-25 |  |  | Civil Crew A [152 h] |
| A24 |  | Piling for process building |  | 17d | 2026-07-02 A | 2026-07-24 A | A23 | 100% |  | 2026-06-26 | 2026-07-13 |  |  | Civil Crew A [136 h] |
| A28 |  | Interconnecting pipework trenching |  | 18d | 2026-07-02 A | 2026-07-27 A | A23 | 100% |  | 2026-06-26 | 2026-07-21 |  |  | Civil Crew B [144 h] |
| A27 |  | Clearwater tank construction |  | 36d | 2026-07-09 A | 2026-08-27 A | A23 FS+5d | 100% |  | 2026-07-03 | 2026-08-13 |  |  | Civil Crew B [288 h] |
| A29 |  | Roads and hardstands |  | 15d | 2026-07-14 A | 2026-08-03 A | A28 FF+5d | 100% |  | 2026-07-08 | 2026-07-28 |  |  | Civil Crew A [120 h] |
| A25 |  | Membrane building foundations |  | 18d | 2026-07-29 A | 2026-08-21 A | A24 FS+2d | 100% |  | 2026-07-16 | 2026-08-10 |  |  | Civil Crew A [144 h] |
| A26 |  | Process building slab and columns |  | 26d | 2026-08-24 A | 2026-09-28 | A25 | 15% | 22.1d | 2026-08-11 | 2026-09-07 | 0d |  | Civil Crew B [208 h] |
| A30 |  | Process building roof and cladding |  | 15d | 2026-09-29 | 2026-10-19 | A26 |  |  | 2026-09-08 | 2026-09-28 | 0d |  | Civil Crew B [120 h] |
| A31 |  | Civil works complete | milestone | 0d | 2026-10-19 | 2026-10-19 | A30, A27, A29 |  |  | 2026-09-28 | 2026-09-28 | 90d |  |  |

| ID | WBS | Activity | Type | Duration | Start | Finish | Predecessors | Complete | Remaining | Planned start | Planned finish | Total float | Free float | Constraint | Resources |
| --- | --- | --- | --- | --- | --- | --- | --- | --- | --- | --- | --- | --- | --- | --- | --- |
|  | 5 | **5 MECHANICAL INSTALLATION** |  |  | 2026-06-19 | 2026-11-26 |  |  |  |  |  |  |  |  |  |
| A35 |  | Process pipework fabrication |  | 25d | 2026-06-19 A | 2026-07-23 | A13 FS+10d | 85% | 3.75d |  |  | 67d | 20d |  | Mechanical Crew [200 h] |
| A36 |  | Process pipework installation |  | 27d | 2026-08-21 A | 2026-11-26 | A35, A33 SS+5d | 15% | 22.95d | 2026-10-06 | 2026-11-04 | 62.05d | 0d |  | Mechanical Crew [216 h] |
| A37 |  | Tank mechanical fit-out |  | 14d | 2026-08-28 | 2026-09-16 | A27 |  |  | 2026-08-14 | 2026-09-02 | 113d | 50.95d |  | Mechanical Crew [112 h] |
| A33 |  | Membrane skids installation |  | 15d | 2026-10-20 | 2026-11-09 | A17, A30 |  |  | 2026-09-29 | 2026-10-19 | 0d |  |  | Mechanical Crew [120 h] |
| A34 |  | Blowers and pumps installation |  | 12d | 2026-10-20 | 2026-11-04 | A18, A30 |  |  | 2026-09-29 | 2026-10-14 | 1d | 0d |  | Mechanical Crew [96 h] |
| A38 |  | Chemical dosing skids install |  | 10d | 2026-11-05 | 2026-11-18 | A34 |  |  | 2026-10-15 | 2026-10-28 | 1d |  |  | Mechanical Crew [80 h] |
| A39 |  | Mechanical completion | milestone | 0d | 2026-11-26 | 2026-11-26 | A36, A37, A38 |  |  | 2026-11-04 | 2026-11-04 | 62.05d |  |  |  |
|  | 6 | **6 ELECTRICAL AND CONTROLS** |  |  | 2026-09-02 | 2026-12-07 |  |  |  |  |  |  |  |  |  |
| A44 |  | SCADA configuration |  | 31d | 2026-09-02 A | 2026-10-14 | A11 FS+15d | 5% | 29.45d | 2026-06-02 | 2026-07-06 | 29d |  |  | Electrical Crew [248 h] |
| A43 |  | Field instrumentation installation |  | 15d | 2026-09-02 | 2026-09-22 | A20, A36 SS+8d |  |  | 2026-10-16 | 2026-11-05 | 42d |  |  | Electrical Crew [120 h] |
| A41 |  | Switchboard installation |  | 10d | 2026-10-20 | 2026-11-02 | A19, A30 |  |  | 2026-09-29 | 2026-10-12 | 0d |  |  | Electrical Crew [80 h] |
| A42 |  | Cable tray and cabling |  | 20d | 2026-10-23 | 2026-11-19 | A41 SS+3d |  |  | 2026-10-02 | 2026-10-29 | 0d |  |  | Electrical Crew [160 h] |
| A45 |  | Loop testing |  | 12d | 2026-11-20 | 2026-12-07 | A42, A43, A44 FS-3d, A38 |  |  | 2026-11-06 | 2026-11-23 | 0d |  |  | Electrical Crew [96 h] |
| A46 |  | Electrical completion | milestone | 0d | 2026-12-07 | 2026-12-07 | A45 |  |  | 2026-11-23 | 2026-11-23 | 55d |  |  |  |
|  | 7 | **7 COMMISSIONING AND HANDOVER** |  |  | 2026-12-08 | 2027-02-22 |  |  |  |  |  |  |  |  |  |
| A48 |  | Pre-commissioning checks |  | 10d | 2026-12-08 | 2026-12-21 | A45 |  |  | 2026-11-24 | 2026-12-07 | 0d |  |  | Commissioning Team [80 h] |
| A49 |  | Water commissioning |  | 15d | 2026-12-22 | 2027-01-11 | A48 |  |  | 2026-12-08 | 2026-12-28 | 0d |  |  | Commissioning Team [120 h] |
| A51 |  | Operator training |  | 8d | 2026-12-29 | 2027-01-07 | A49 SS+5d |  |  | 2026-12-15 | 2026-12-24 | 25d |  |  | Commissioning Team [64 h] |
| A50 |  | Process proving and performance test |  | 20d | 2027-01-12 | 2027-02-08 | A49 |  |  | 2026-12-29 | 2027-01-25 | 0d |  |  | Commissioning Team [160 h] |
| A52 |  | As-built documentation |  | 12d | 2027-01-12 | 2027-01-27 | A50 SS |  |  | 2026-12-29 | 2027-01-13 | 18d |  |  | Project Controls [96 h] |
| A53 |  | Defects close-out |  | 10d | 2027-02-09 | 2027-02-22 | A50 |  |  | 2027-01-26 | 2027-02-08 | 0d |  |  | Commissioning Team [80 h] |
| A54 |  | SUBSTANTIAL COMPLETION | milestone | 0d | 2027-02-12 | 2027-02-12 | A50, A51 |  |  |  |  | 0d |  | mandatory finish 2027-02-12 |  |
| A55 |  | Final handover | milestone | 0d | 2027-02-22 | 2027-02-22 | A52, A53 |  |  | 2027-02-08 | 2027-02-08 | 0d |  |  |  |
