# Riverbend WTP Upgrade - Update 05 (Sample Project)

Schedule from MS Project, 2026-03-02 to 2027-02-12, status date 2026-07-31, A marks actual dates.

## Calendars

- Standard: Mon-Fri 08:00-12:00, 13:00-17:00; Sat-Sun off.

## Resources

| Resource |
| --- |
| Civil Crew A |
| Project Controls |
| Design Team |
| Procurement |
| Civil Crew B |
| Mechanical Crew |
| Electrical Crew |
| Commissioning Team |

## Schedule

| ID | WBS | Task | Type | Duration | Start | Finish | Predecessors | Complete | Remaining | Baseline start | Baseline finish | Baseline duration | Total slack | Free slack | Constraint | Resources | Work | Actual work |
| --- | --- | --- | --- | --- | --- | --- | --- | --- | --- | --- | --- | --- | --- | --- | --- | --- | --- | --- |
| 1 | 1 | **1 PROJECT INITIATION** |  | 15d? | 2026-03-02 A | 2026-03-20 |  | 87% | 2d? | 2026-03-02 | 2026-03-20 | 15d? | 235d |  |  |  | 240h | 240h |
| 2 | 1.1 | Notice to proceed | milestone | 0d? | 2026-03-02 A | 2026-03-02 A |  | 100% |  | 2026-03-02 | 2026-03-02 | 0d? |  |  | must start on 2026-03-02 |  |  |  |
| 3 | 1.2 | Mobilise site facilities |  | 10d? | 2026-03-02 A | 2026-03-13 A | 2 | 100% |  | 2026-03-02 | 2026-03-13 | 10d? |  |  |  | Civil Crew A | 80h | 80h |
| 4 | 1.3 | Baseline schedule approved |  | 8d? | 2026-03-02 A | 2026-03-11 A | 2 | 100% |  | 2026-03-02 | 2026-03-11 | 8d? |  |  |  | Project Controls | 64h | 64h |
| 5 | 1.4 | Site survey and geotech verification |  | 12d? | 2026-03-04 A | 2026-03-19 A | 3SS+2d | 100% |  | 2026-03-04 | 2026-03-19 | 12d? |  |  |  | Design Team | 96h | 96h |
| 6 | 1.5 | Permits and consents confirmed |  | 15d? | 2026-03-02 A | 2026-03-20 | 2 | 60% | 6d? | 2026-03-02 | 2026-03-20 | 15d? | 235d |  |  |  |  |  |
| 7 | 2 | **2 DETAILED DESIGN** |  | 55d? | 2026-03-20 A | 2026-06-04 A |  | 100% |  | 2026-03-20 | 2026-06-04 | 55d? |  |  |  |  | 928h | 928h |
| 8 | 2.1 | Process design report |  | 23d? | 2026-03-20 A | 2026-04-21 A | 4, 5 | 100% |  | 2026-03-20 | 2026-04-16 | 20d? |  |  |  | Design Team | 184h | 184h |
| 9 | 2.2 | Civil and structural design |  | 29d? | 2026-03-27 A | 2026-05-06 A | 8SS+5d | 100% |  | 2026-03-27 | 2026-04-30 | 25d? |  |  |  | Design Team | 232h | 232h |
| 10 | 2.3 | Mechanical design |  | 22d? | 2026-04-01 A | 2026-04-30 A | 8SS+8d | 100% |  | 2026-04-01 | 2026-04-30 | 22d? |  |  |  | Design Team | 176h | 176h |
| 11 | 2.4 | Electrical and controls design |  | 24d? | 2026-04-08 A | 2026-05-11 A | 10SS+5d | 100% |  | 2026-04-08 | 2026-05-11 | 24d? |  |  |  | Design Team | 192h | 192h |
| 12 | 2.5 | HAZOP workshop and close-out |  | 8d? | 2026-05-12 A | 2026-05-21 A | 9, 10, 11 | 100% |  | 2026-05-12 | 2026-05-21 | 8d? |  |  |  | Design Team | 64h | 64h |
| 13 | 2.6 | Issued for construction drawings |  | 10d? | 2026-05-22 A | 2026-06-04 A | 12 | 100% |  | 2026-05-22 | 2026-06-04 | 10d? |  |  |  | Design Team | 80h | 80h |
| 14 | 2.7 | Design review milestone | milestone | 0d? | 2026-05-21 A | 2026-05-21 A | 12 | 100% |  | 2026-05-21 | 2026-05-21 | 0d? |  |  |  |  |  |  |
| 15 | 3 | **3 PROCUREMENT** |  | 121d? | 2026-03-02 A | 2026-08-17 |  | 91% | 10.34d? | 2026-03-02 | 2026-07-27 | 106d? | 129d |  |  |  | 1872h | 1712h |
| 16 | 3.1 | Membrane skid supply contract |  | 12d? | 2026-04-22 A | 2026-05-07 A | 8 | 100% |  | 2026-04-17 | 2026-05-04 | 12d? |  |  |  | Procurement | 96h | 96h |
| 17 | 3.2 | Membrane skids fabrication and delivery |  | 72d? | 2026-05-08 A | 2026-08-17 | 16 | 83% | 12d? | 2026-05-05 | 2026-07-27 | 60d? | 39d |  |  | Procurement | 576h | 480h |
| 18 | 3.3 | Blowers and pumps procurement |  | 45d? | 2026-05-01 A | 2026-07-02 A | 10 | 100% |  | 2026-05-01 | 2026-07-02 | 45d? |  |  |  | Procurement | 360h | 360h |
| 19 | 3.4 | Switchboard and VSD procurement |  | 50d? | 2026-05-12 A | 2026-07-20 A | 11 | 100% |  | 2026-05-12 | 2026-07-20 | 50d? |  |  |  | Procurement | 400h | 400h |
| 20 | 3.5 | Instrumentation package |  | 35d? | 2026-05-12 A | 2026-06-29 A | 11 | 100% |  | 2026-05-12 | 2026-06-29 | 35d? |  |  |  | Procurement | 280h | 280h |
| 21 | 3.6 | Spare parts and consumables order |  | 20d? | 2026-03-02 A | 2026-03-27 |  | 60% | 8d? | 2026-03-02 | 2026-03-27 | 20d? | 230d |  |  | Procurement | 160h | 96h |
| 22 | 4 | **4 CIVIL WORKS** |  | 91d? | 2026-06-05 A | 2026-10-09 |  | 54% | 42.04d? | 2026-06-05 | 2026-09-28 | 82d? | 90d |  |  |  | 1264h | 680h |
| 23 | 4.1 | Bulk earthworks |  | 19d? | 2026-06-05 A | 2026-07-01 A | 13 | 100% |  | 2026-06-05 | 2026-06-25 | 15d? |  |  |  | Civil Crew A | 152h | 152h |
| 24 | 4.2 | Piling for process building |  | 17d? | 2026-07-02 A | 2026-07-24 A | 23 | 100% |  | 2026-06-26 | 2026-07-13 | 12d? |  |  |  | Civil Crew A | 136h | 136h |
| 25 | 4.3 | Membrane building foundations |  | 18d? | 2026-07-29 A | 2026-08-21 | 24FS+2d | 11% | 16d? | 2026-07-16 | 2026-08-10 | 18d? | -1d | 0d |  | Civil Crew A | 144h | 16h |
| 26 | 4.4 | Process building slab and columns |  | 20d? | 2026-08-24 | 2026-09-18 | 25 |  |  | 2026-08-11 | 2026-09-07 | 20d? | -1d | 0d |  | Civil Crew B | 160h |  |
| 27 | 4.5 | Clearwater tank construction |  | 36d? | 2026-07-09 A | 2026-08-27 | 23FS+5d | 44% | 20d? | 2026-07-03 | 2026-08-13 | 30d? | 107d | 0d |  | Civil Crew B | 288h | 128h |
| 28 | 4.6 | Interconnecting pipework trenching |  | 18d? | 2026-07-02 A | 2026-07-27 A | 23 | 100% |  | 2026-06-26 | 2026-07-21 | 18d? |  |  |  | Civil Crew B | 144h | 144h |
| 29 | 4.7 | Roads and hardstands |  | 15d? | 2026-07-14 A | 2026-08-03 | 28FF+5d | 87% | 2d? | 2026-07-08 | 2026-07-28 | 15d? | 139d | 49d |  | Civil Crew A | 120h | 104h |
| 30 | 4.8 | Process building roof and cladding |  | 15d? | 2026-09-21 | 2026-10-09 | 26 |  |  | 2026-09-08 | 2026-09-28 | 15d? | -1d | 0d |  | Civil Crew B | 120h |  |
| 31 | 4.9 | Civil works complete | milestone | 0d? | 2026-10-09 | 2026-10-09 | 30, 27, 29 |  |  | 2026-09-28 | 2026-09-28 | 0d? | 90d |  |  |  |  |  |

| ID | WBS | Task | Type | Duration | Start | Finish | Predecessors | Complete | Remaining | Baseline start | Baseline finish | Baseline duration | Total slack | Free slack | Constraint | Resources | Work | Actual work |
| --- | --- | --- | --- | --- | --- | --- | --- | --- | --- | --- | --- | --- | --- | --- | --- | --- | --- | --- |
| 32 | 5 | **5 MECHANICAL INSTALLATION** |  | 104.7d? | 2026-06-19 A | 2026-11-12 |  | 25% | 78.47d? | 2026-06-19 | 2026-11-04 | 99d? | 66.3d |  |  |  | 784h | 196.4h |
| 33 | 5.1 | Membrane skids installation |  | 15d? | 2026-10-12 | 2026-10-30 | 17, 30 |  |  | 2026-09-29 | 2026-10-19 | 15d? | 0d |  |  | Mechanical Crew | 120h |  |
| 34 | 5.2 | Blowers and pumps installation |  | 12d? | 2026-10-12 | 2026-10-27 | 18, 30 |  |  | 2026-09-29 | 2026-10-14 | 12d? | 68d | 0d |  | Mechanical Crew | 96h |  |
| 35 | 5.3 | Process pipework fabrication |  | 25d? | 2026-06-19 A | 2026-07-23 | 13FS+10d | 85% | 3.75d? | 2026-06-19 | 2026-07-23 | 25d? | 61d | 0d |  | Mechanical Crew | 200h | 170h |
| 36 | 5.4 | Process pipework installation |  | 22d? | 2026-07-24 A | 2026-11-12 | 35, 33SS+5d | 15% | 18.7d? | 2026-10-06 | 2026-11-04 | 22d? | 66.3d | 0d |  | Mechanical Crew | 176h | 26.4h |
| 37 | 5.5 | Tank mechanical fit-out |  | 14d? | 2026-08-28 | 2026-09-16 | 27 |  |  | 2026-08-14 | 2026-09-02 | 14d? | 107d | 40.7d |  | Mechanical Crew | 112h |  |
| 38 | 5.6 | Chemical dosing skids install |  | 10d? | 2026-10-28 | 2026-11-10 | 34 |  |  | 2026-10-15 | 2026-10-28 | 10d? | 68d | 1.7d |  | Mechanical Crew | 80h |  |
| 39 | 5.7 | Mechanical completion | milestone | 0d? | 2026-11-12 | 2026-11-12 | 36, 37, 38 |  |  | 2026-11-04 | 2026-11-04 | 0d? | 66.3d |  |  |  |  |  |
| 40 | 6 | **6 ELECTRICAL AND CONTROLS** |  | 83d? | 2026-08-05 A | 2026-11-27 |  | 2% | 81.73d? | 2026-06-02 | 2026-11-23 | 125d? | 55d |  |  |  | 656h | 10h |
| 41 | 6.1 | Switchboard installation |  | 10d? | 2026-10-12 | 2026-10-23 | 19, 30 |  |  | 2026-09-29 | 2026-10-12 | 10d? | -1d | 0d |  | Electrical Crew | 80h |  |
| 42 | 6.2 | Cable tray and cabling |  | 20d? | 2026-10-15 | 2026-11-11 | 41SS+3d |  |  | 2026-10-02 | 2026-10-29 | 20d? | -1d | 0d |  | Electrical Crew | 160h |  |
| 43 | 6.3 | Field instrumentation installation |  | 15d? | 2026-08-05 | 2026-08-25 | 20, 36SS+8d |  |  | 2026-10-16 | 2026-11-05 | 15d? | 55d |  |  | Electrical Crew | 120h |  |
| 44 | 6.4 | SCADA configuration |  | 25d? | 2026-08-05 A | 2026-09-08 | 11FS+15d | 5% | 23.75d? | 2026-06-02 | 2026-07-06 | 25d? | 48d |  |  | Electrical Crew | 200h | 10h |
| 45 | 6.5 | Loop testing |  | 12d? | 2026-11-12 | 2026-11-27 | 42, 43, 44FS-3d |  |  | 2026-11-06 | 2026-11-23 | 12d? | -1d | 0d |  | Electrical Crew | 96h |  |
| 46 | 6.6 | Electrical completion | milestone | 0d? | 2026-11-27 | 2026-11-27 | 45 |  |  | 2026-11-23 | 2026-11-23 | 0d? | 55d |  |  |  |  |  |
| 47 | 7 | **7 COMMISSIONING AND HANDOVER** |  | 55d? | 2026-11-30 | 2027-02-12 |  |  |  | 2026-11-24 | 2027-02-08 | 55d? | -1d | 0d |  |  | 600h |  |
| 48 | 7.1 | Pre-commissioning checks |  | 10d? | 2026-11-30 | 2026-12-11 | 45 |  |  | 2026-11-24 | 2026-12-07 | 10d? | -1d | 0d |  | Commissioning Team | 80h |  |
| 49 | 7.2 | Water commissioning |  | 15d? | 2026-12-14 | 2027-01-01 | 48 |  |  | 2026-12-08 | 2026-12-28 | 15d? | -1d | 0d |  | Commissioning Team | 120h |  |
| 50 | 7.3 | Process proving and performance test |  | 20d? | 2027-01-04 | 2027-01-29 | 49 |  |  | 2026-12-29 | 2027-01-25 | 20d? | -1d | 0d |  | Commissioning Team | 160h |  |
| 51 | 7.4 | Operator training |  | 8d? | 2026-12-21 | 2026-12-30 | 49SS+5d |  |  | 2026-12-15 | 2026-12-24 | 8d? | 21d |  |  | Commissioning Team | 64h |  |
| 52 | 7.5 | As-built documentation |  | 12d? | 2027-01-04 | 2027-01-19 | 50SS |  |  | 2026-12-29 | 2027-01-13 | 12d? | 18d |  |  | Project Controls | 96h |  |
| 53 | 7.6 | Defects close-out |  | 10d? | 2027-02-01 | 2027-02-12 | 50 |  |  | 2027-01-26 | 2027-02-08 | 10d? | 0d |  |  | Commissioning Team | 80h |  |
| 54 | 7.7 | SUBSTANTIAL COMPLETION | milestone | 0d? | 2027-01-29 | 2027-01-29 | 50, 51 |  |  | 2027-01-29 | 2027-01-29 | 0d? | -1d | 0d | must finish on 2027-01-29 |  |  |  |
| 55 | 7.8 | Final handover | milestone | 0d? | 2027-02-12 | 2027-02-12 | 52, 53 |  |  | 2027-02-08 | 2027-02-08 | 0d? | 0d |  |  |  |  |  |
